# BB-05 - met dragend metselwerk

Schedule from MS Project, 2003-01-12 to 2003-02-10, status date 2003-01-08.
BAM Nelissen Van Egteren

## Calendars

- ALLEEN WERKDAGEN: Mon-Fri 08:30-12:30, 13:00-17:00; Sat-Sun off. Exceptions (off unless hours are given): 2003-01-11 to 2003-01-12 08:30-12:30, 13:00-17:00, 2003-01-18 to 2003-01-19 08:30-12:30, 13:00-17:00, 2003-01-25 to 2003-01-26 08:30-12:30, 13:00-17:00, 2003-02-01 to 2003-02-02 08:30-12:30, 13:00-17:00, 2003-02-08 to 2003-02-09 08:30-12:30, 13:00-17:00.

## Schedule

| ID | WBS | Task | Type | Duration | Start | Finish | Predecessors | Total slack |
| --- | --- | --- | --- | --- | --- | --- | --- | --- |
| 1 | 1 | **BOVENBOUWFASE** |  | 30d | 2003-01-12 | 2003-02-10 |  | 0d |
| 2 | 1.1 | beg.grond kozijnen+profielen |  | 3d | 2003-01-12 | 2003-01-14 |  | 0d |
| 3 | 1.2 | beg.grond metselen 1e slag |  | 4d | 2003-01-14 | 2003-01-17 | 2SS+2d | 0d |
| 4 | 1.3 | steiger opbouwen vanaf maaiv |  | 2d | 2003-01-17 | 2003-01-18 | 3SS+3d | 0d |
| 5 | 1.4 | beg.grond metselen 2e slag |  | 4d | 2003-01-18 | 2003-01-21 | 4SS+1d | 0d |
| 6 | 1.5 | 1e verd,vloer breedplaat+stempels |  | 2d | 2003-01-22 | 2003-01-23 | 5SS+4d | 0d |
| 7 | 1.6 | 1e verd.vloer wapening+beton |  | 1d | 2003-01-24 | 2003-01-24 | 6SS+2d | 0d |
| 8 | 1.7 | 1e verd. kozijnen+profielen |  | 2d | 2003-01-25 | 2003-01-26 | 7SS+1d | 0d |
| 9 | 1.8 | 1e verd. metselen 3e slag |  | 4d | 2003-01-27 | 2003-01-30 | 8SS+2d | 0d |
| 10 | 1.9 | steiger verder opbouwen |  | 2d | 2003-01-30 | 2003-01-31 | 9SS+3d | 0d |
| 11 | 1.10 | 1e verd. metselen 4e slag |  | 4d | 2003-01-31 | 2003-02-03 | 10SS+1d | 0d |
| 12 | 1.11 | zoldervloer breedplaat+stempels |  | 2d | 2003-02-04 | 2003-02-05 | 11SS+4d | 0d |
| 13 | 1.12 | zoldervloer wapening+beton |  | 1d | 2003-02-06 | 2003-02-06 | 12SS+2d | 0d |
| 14 | 1.13 | zolder kozijnen+profielen |  | 2d | 2003-02-07 | 2003-02-08 | 13SS+1d | 0d |
| 15 | 1.14 | zolder toppen metselen |  | 3d | 2003-02-08 | 2003-02-10 | 14SS+1d | 0d |
| 16 | 1.15 | start gevel/dak fase | milestone | 0d | 2003-02-10 | 2003-02-10 | 15SS+3d | 0d |
